# Elena general site planning2

Schedule from MS Project, 2012-02-01 to 2017-11-17, A marks actual dates.
CERN

## Calendars

- Standard: Mon-Fri 08:00-12:00, 13:00-17:00; Sat-Sun off. Exceptions (off unless hours are given): 2012-12-24 to 2013-01-06 (Xmas 1213), 2013-12-23 to 2014-01-05 (Xmas 1314), 2014-12-22 to 2015-01-04 (Xmas 1415), 2015-12-21 to 2016-01-03 (Xmas 1516), 2016-12-22 to 2017-01-04 (Xmas 1617).

## Schedule

| ID | WBS | Task | Type | Duration | Start | Finish | Complete | Remaining | Total slack | Free slack | Constraint | Text2 | Text1 |
| --- | --- | --- | --- | --- | --- | --- | --- | --- | --- | --- | --- | --- | --- |
| 1 | 1 | **General milestones** |  | 1d? | 2012-02-01 | 2012-02-01 |  |  |  |  |  |  |  |
| 2 | 1.1 | Ring optics & layout | milestone | 0d | 2012-04-30 | 2012-04-30 |  |  | 1400d |  | start no earlier than 2012-04-30 | _key date |  |
| 3 | 1.2 | Transfert lines optics & layout | milestone | 0d | 2012-05-31 | 2012-05-31 |  |  | 1377d |  | start no earlier than 2012-05-31 | _key date |  |
| 4 | 1.3 | General layout hall 193 and annexed bldg | milestone | 0d | 2012-09-03 | 2012-09-03 |  |  | 1310d |  | start no earlier than 2012-09-03 | _key date |  |
| 5 | 1.4 | TDR Elena project | milestone | 0d | 2012-10-15 | 2012-10-15 |  |  | 1280d |  | start no earlier than 2012-10-15 | _key date |  |
| 6 | 1.5 | TDR Gbar project | milestone | 0d | 2012-12-14 | 2012-12-14 |  |  | 1236d |  | start no earlier than 2012-12-14 | _key date |  |
| 7 | 1.6 | LS1 (for AD machine) |  | 347d? | 2012-12-04 | 2014-04-30 |  |  | 897d | 0d | finish no earlier than 2014-04-30 | _key date |  |
| 8 | 1.7 | AD shutdown 2014-15 |  | 110d | 2014-12-01 | 2015-05-15 |  |  | 635d | 0d | finish no earlier than 2015-05-15 | _key date |  |
| 9 | 1.8 | AD shutdown 2015-16 |  | 60d | 2015-12-01 | 2016-03-07 |  |  | -1028d | 0d | start no earlier than 2015-12-01 | _key date |  |
| 10 | 1.9 | AD shutdown 2016-17 |  | 60d | 2016-12-01 | 2017-03-08 |  |  | 182d |  | start no earlier than 2016-12-01 | _key date |  |
| 11 | 1.10 | **Finance Committee meetings 2012** |  | 125d | 2012-06-20 | 2012-12-12 |  |  | -224d | 0d |  | _key date |  |
| 12 | 1.10.1 | Committee 1 | milestone | 0d | 2012-06-20 | 2012-06-20 |  |  | -99d | 0d | start no earlier than 2012-06-20 |  |  |
| 13 | 1.10.2 | Committee 2 | milestone | 0d | 2012-09-19 | 2012-09-19 |  |  | -164d | 0d | start no earlier than 2012-09-19 |  |  |
| 14 | 1.10.3 | Committee 3 (to be confirmed) | milestone | 0d | 2012-11-07 | 2012-11-07 |  |  | -199d | 0d | start no earlier than 2012-11-07 |  |  |
| 15 | 1.10.4 | Committee 4 | milestone | 0d | 2012-12-12 | 2012-12-12 |  |  | -224d | 0d | start no earlier than 2012-12-12 |  |  |
| 16 | 1.11 | **Finance Committee meetings 2013** |  | 0d | 2013-03-13 | 2013-03-13 |  |  | -279d | 0d |  | _key date |  |
| 17 | 1.11.1 | Committee 1 | milestone | 0d | 2013-03-13 | 2013-03-13 |  |  | -279d | 0d | start no earlier than 2013-03-13 |  |  |
| 19 | 2 | **Studies & purchasing activities** |  | 709d? | 2012-05-31 A | 2015-03-31 |  | 709d? | 668d |  |  |  |  |
| 20 | 2.1 | **Annexed building** |  | 131d | 2012-05-31 A | 2012-11-30 |  | 131d | 1246d |  |  | GS/SE | L.A. Lopez |
| 21 | 2.1.1 | Building approval | milestone | 0d | 2012-05-31 A | 2012-05-31 A | 100% |  |  |  | start no earlier than 2012-05-31 | GS/SE | L.A. Lopez |
| 22 | 2.1.2 | Drawings/specification/documents |  | 16w | 2012-07-12 | 2012-10-31 |  |  | 1267d |  | finish no earlier than 2012-10-31 | GS/SE | L.A. Lopez |
| 23 | 2.1.3 | Annexed building CFT | milestone | 0d | 2012-11-01 | 2012-11-01 |  |  | 1267d |  | start no earlier than 2012-11-01 | GS/SE | L.A. Lopez |
| 24 | 2.1.4 | Finance Committee | milestone | 0d | 2012-11-30 | 2012-11-30 |  |  | 1246d |  | start no earlier than 2012-11-30 | GS/SE | L.A. Lopez |
| 25 | 2.2 | **Magnets** |  | 622d | 2012-10-01 | 2015-03-31 |  |  | -319d | 0d |  | TE/MSC | Th. Zickler |
| 26 | 2.2.1 | Prototype completed | milestone | 0d | 2012-10-01 | 2012-10-01 |  |  | 1290d |  | start no earlier than 2012-10-01 | TE/MSC | Th. Zickler |
| 27 | 2.2.2 | Detailed study dipoles completed (3D plans, layout) | milestone | 0d | 2012-12-21 | 2012-12-21 |  |  | 1231d |  | start no earlier than 2012-12-21 | TE/MSC | Th. Zickler |
| 28 | 2.2.3 | 1st dipole magnet (pre-series) | milestone | 0d | 2014-05-15 | 2014-05-15 |  |  | 887d |  | start no earlier than 2014-05-15 | TE/MSC | Th. Zickler |
| 29 | 2.2.4 | start-up dipole manufacturing | milestone | 0d | 2014-08-01 | 2014-08-01 |  |  | 831d |  | start no earlier than 2014-08-01 | TE/MSC | Th. Zickler |
| 30 | 2.2.5 | End dipole manufacturing | milestone | 0d | 2015-03-01 | 2015-03-01 |  |  | 690d |  | start no earlier than 2015-03-01 | TE/MSC | Th. Zickler |
| 31 | 2.2.6 | Magnet test campaing (at CERN) |  | 97d | 2014-11-03 | 2015-03-31 |  |  | -844d | 0d | start no earlier than 2014-11-03 | TE/MSC | Th. Zickler |

| ID | WBS | Task | Type | Duration | Start | Finish | Predecessors | Total slack | Free slack | Constraint | Text1 | Text2 |
| --- | --- | --- | --- | --- | --- | --- | --- | --- | --- | --- | --- | --- |
| 32 | 2.3 | **Kickers** |  | 500d? | 2013-01-07 | 2015-01-05 |  | 730d |  |  | L. Sermeus | TE/ABT |
| 33 | 2.3.1 | Purchase order phase |  | 60d? | 2013-01-07 | 2013-03-31 |  | 1170d |  | finish no earlier than 2013-03-31 | L. Sermeus | TE/ABT |
| 34 | 2.3.2 | Deliveries |  | 360d? | 2013-06-03 | 2014-10-31 |  | 765d |  | finish no earlier than 2014-10-31 | L. Sermeus | TE/ABT |
| 35 | 2.3.3 | Tests in labo CERN |  | 124d? | 2014-07-01 | 2014-12-19 |  | 730d |  | finish no earlier than 2014-12-19 | L. Sermeus | TE/ABT |
| 36 | 2.3.4 | Ready for installation | milestone | 0d | 2015-01-05 | 2015-01-05 |  | 730d |  | start no earlier than 2015-01-05 | L. Sermeus | TE/ABT |
| 37 | 2.4 | **Various** |  | 0d | 2013-11-11 | 2013-11-11 |  | 1010d |  |  |  |  |
| 38 | 2.4.1 | Purchase order travelling crane | milestone | 0d | 2013-11-11 | 2013-11-11 | 51SF-5mo | 1010d |  |  | C. Bertone | EN/HE |
| 40 | 3 | **Annexed building** |  | 1d? | 2012-02-01 | 2012-02-01 |  |  |  |  |  |  |
| 41 | 3.1 | **Construction** |  | 289d | 2013-03-04 | 2014-04-25 |  | -561d | 0d |  | L.A. Lopez | GS/SE |
| 42 | 3.1.1 | Move cable trays inside hall 193 |  | 40d | 2013-03-04 | 2013-04-26 |  | -312d | 0d | start no earlier than 2013-03-04 | P. Lelong | EN/EL |
| 43 | 3.1.2 | Mound excavation |  | 35d | 2013-04-15 | 2013-05-31 |  | -337d | 0d | finish no earlier than 2013-05-31 | L.A. Lopez | GS/SE |
| 44 | 3.1.3 | Foundations |  | 65d | 2013-06-03 | 2013-08-31 |  | -402d | 0d | finish no earlier than 2013-08-31 | L.A. Lopez | GS/SE |
| 45 | 3.1.4 | Earthing network |  | 10d | 2013-06-17 | 2013-06-28 |  | -357d | 0d | start no earlier than 2013-06-17 | R. Necca | EN/EL |
| 46 | 3.1.5 | Metal structure |  | 80d | 2013-09-02 | 2013-12-20 |  | -482d | 0d | finish no earlier than 2013-12-20 | L.A. Lopez | GS/SE |
| 47 | 3.1.6 | Roof - cladding/siding - gutters - doors |  | 76d | 2013-12-02 | 2014-03-31 |  | -543d | 0d | start no earlier than 2013-12-02 | L.A. Lopez | GS/SE |
| 48 | 3.1.7 | Coating floor |  | 15d | 2014-04-01 | 2014-04-21 |  | -558d | 0d | start no earlier than 2014-04-01 | L.A. Lopez | GS/SE |
| 49 | 3.1.8 | Annexed bldg delivery | milestone | 0d | 2014-04-25 | 2014-04-25 |  | -561d | 0d | start no earlier than 2014-04-25 | L.A. Lopez | GS/SE |
| 50 | 3.2 | **Installation equipment in annexed bldg** |  | 265d | 2014-04-28 | 2015-05-15 |  | -827d | 0d |  |  |  |
| 51 | 3.2.1 | Travelling crane |  | 10d | 2014-04-28 | 2014-05-09 |  | -572d | 0d | start no earlier than 2014-04-28 | C. Bertone | EN/HE |
| 52 | 3.2.2 | Electrical services |  | 100d | 2014-05-12 | 2014-09-26 |  | -672d | 0d | start no earlier than 2014-05-12 | R. Necca | EN/EL |
| 53 | 3.2.3 | Cooling & ventilation installation |  | 3mo | 2014-06-16 | 2014-09-15 |  | -663d | 0d | start no earlier than 2014-06-16 | M. Battistin | EN/CV |
| 54 | 3.2.4 | Install new supporting frame |  | 10d | 2014-09-29 | 2014-10-10 |  | -682d | 0d | start no earlier than 2014-09-29 | L. Sermeus | TE/ABT |
| 55 | 3.2.5 | Dismantling kickers platform and accessories |  | 10d | 2014-12-01 | 2014-12-12 |  | -932d | 0d | start no earlier than 2014-12-01 | L. Sermeus | TE/ABT |
| 56 | 3.2.6 | Migration kicker equipment to annexed bldg |  | 15d | 2014-12-15 | 2015-01-16 | 55 | -932d | 0d |  | L. Sermeus | TE/ABT |
| 57 | 3.2.7 | Electrical works (cabinet, cabling, connectors) |  | 60d | 2015-01-12 | 2015-04-03 |  | -797d | 0d | start no earlier than 2015-01-12 | P. Lelong | EN/EL |
| 58 | 3.2.8 | Kickers commissioning |  | 30d | 2015-04-06 | 2015-05-15 |  | -827d | 0d | start no earlier than 2015-04-06 | L. Sermeus | TE/ABT |

| ID | WBS | Task | Type | Duration | Start | Finish | Predecessors | Total slack | Free slack | Constraint | Text2 | Text1 | Text3 |
| --- | --- | --- | --- | --- | --- | --- | --- | --- | --- | --- | --- | --- | --- |
| 60 | 3.3 | **Miscellaneous activities** |  | 44d | 2012-07-02 | 2012-08-30 |  | -151d | 0d |  | _key date |  |  |
| 61 | 3.3.1 | External control room (stage 2) |  | 2mo | 2012-07-02 | 2012-08-30 |  | -151d | 0d | start no earlier than 2012-07-02 | EN/MEF | F. Butin | tbd |
| 63 | 4 | **Redevelopment Hall 193** |  | 1d? | 2012-02-01 | 2012-02-01 |  |  |  |  |  |  |  |
| 64 | 4.1 | **Implementation AD ring /target access point** |  | 132d | 2013-08-01 | 2014-02-14 |  | -512d | 0d |  | GS/ASE | E. Sanchez |  |
| 65 | 4.1.1 | Reorganise shielding blocks AD access point |  | 22d | 2013-08-01 | 2013-08-30 |  | -482d | 0d | finish no earlier than 2013-08-30 | EN/HE | S. Pelletier |  |
| 66 | 4.1.2 | Install AD ring/target new access points |  | 44d | 2013-09-02 | 2013-10-31 |  | -446d | 0d | start no earlier than 2013-09-02 | GS/ASE | E. Sanchez |  |
| 67 | 4.1.3 | Commissioning AD ring/target access point |  | 2w | 2014-02-03 | 2014-02-14 |  | -512d | 0d | start no earlier than 2014-02-03 | GS/ASE | E. Sanchez |  |
| 68 | 4.2 | AD hall preparation / cleaning |  | 30d | 2014-09-29 | 2014-11-10 | 70SF | -702d | 0d |  | EN/HE | S. Pelletier |  |
| 69 | 4.3 | Redevelopment existing racks / platforms |  | 50d | 2014-11-03 | 2015-01-23 |  | -857d | 0d | start no earlier than 2014-11-03 | EN/HE | S. Pelletier |  |
| 70 | 4.4 | AD hall moving (workshop, experiments) |  | 15d | 2014-11-10 | 2014-11-28 |  | -907d | 0d | start no earlier than 2014-11-10 | EN/HE | S. Pelletier |  |
| 71 | 4.5 | Installation new gangways / stairs |  | 36d | 2015-01-26 | 2015-03-16 | 69 | -783d | 0d |  | EN/MEF | F. Butin |  |
| 73 | 5 | **Elena machine installation** |  | 1d? | 2012-02-01 | 2012-02-01 |  |  |  |  |  |  |  |
| 74 | 5.1 | Empty storag area above ring |  | 5d | 2013-05-27 | 2013-05-31 |  | 1125d |  | start no earlier than 2013-05-27 | EN/HE | S. Pelletier |  |
| 75 | 5.2 | Removal BHZ 8000 |  | 15d | 2013-06-03 | 2013-06-21 |  | 1110d |  | start no earlier than 2013-06-03 | EN/HE | S. Pelletier |  |
| 76 | 5.3 | Removal old line 8000 (p+ injection) |  | 30d | 2013-06-24 | 2013-08-02 |  | 1080d |  | start no earlier than 2013-06-24 | EN/HE | S. Pelletier |  |
| 77 | 5.4 | Modification line 7000 (if possible ?) |  | 65d | 2013-09-02 | 2013-11-29 | 65 | -482d | 0d |  |  |  |  |
| 78 | 5.5 | Shielding & storage back in place (+ breach) |  | 15d | 2013-12-02 | 2013-12-20 | 77 | -482d | 0d |  | EN/HE | S. Pelletier |  |
| 79 | 5.6 | Closing AD ring (end of LS1) | milestone | 0d | 2014-04-30 | 2014-04-30 | 7 | 897d |  | finish no earlier than 2013-11-15 | _key date |  |  |
| 80 | 5.7 | AD stop / re-opening | milestone | 0d | 2014-12-01 | 2014-12-01 | 8SS | 745d |  | finish no earlier than 2013-11-15 | _key date |  |  |
| 81 | 5.8 | Survey marking (incl. Gbar and H- source) |  | 5d | 2015-01-19 | 2015-01-23 | 70, 56 | -932d | 0d |  | BE/ABP | T. Dobers |  |
| 82 | 5.9 | Install surrounding concrete shielding |  | 5d | 2015-01-26 | 2015-01-30 | 81 | -932d | 0d |  | EN/HE | S. Pelletier |  |
| 83 | 5.10 | Equip control racks |  | 5mo | 2015-01-26 | 2015-06-26 | 69 | -857d | 0d |  |  |  |  |
| 84 | 5.11 | Cable trays / lightning / AC cabling |  | 20d | 2015-02-02 | 2015-02-27 | 82 | -812d | 0d |  | EN/EL | R. Necca |  |
| 85 | 5.12 | Install cooling network |  | 40d | 2015-03-02 | 2015-04-24 | 84 | -812d | 0d |  | EN/CV | St. Moccia |  |

| ID | WBS | Task | Type | Duration | Start | Finish | Predecessors | Total slack | Free slack | Constraint | Text1 | Text2 |
| --- | --- | --- | --- | --- | --- | --- | --- | --- | --- | --- | --- | --- |
| 86 | 5.13 | **H- source** |  | 180d | 2015-02-02 | 2015-10-09 |  | -932d | 0d |  | D. Kuchler | BE/ABP |
| 87 | 5.13.1 | Installation source |  | 20d | 2015-02-02 | 2015-02-27 | 82 | -932d | 0d |  | D. Kuchler | BE/ABP |
| 88 | 5.13.2 | Cabling and Control |  | 40d | 2015-03-02 | 2015-04-24 | 87 | -932d | 0d |  | D. Kuchler | BE/ABP |
| 89 | 5.13.3 | Add vacuum / test line |  | 20d | 2015-04-27 | 2015-05-22 | 88 | -932d | 0d |  | D. Kuchler | BE/ABP |
| 90 | 5.13.4 | Commissioning source |  | 80d | 2015-05-25 | 2015-09-11 | 89 | -932d | 0d |  | D. Kuchler | BE/ABP |
| 91 | 5.13.5 | Connection to ELENA machine |  | 20d | 2015-09-14 | 2015-10-09 | 90 | -932d | 0d |  | D. Kuchler | BE/ABP |
| 92 | 5.14 | Magnet installation |  | 50d | 2015-04-01 | 2015-06-09 | 31 | -844d | 0d |  | Th. Zickler | TE/MSC |
| 93 | 5.15 | Cable-laying campaign |  | 5mo | 2015-04-15 | 2015-09-15 |  | 548d |  | start no earlier than 2015-04-15 | P. Lelong | EN/EL |
| 94 | 5.16 | Install kickers |  | 2mo | 2015-04-29 | 2015-06-29 |  | 604d |  | start no earlier than 2015-04-29 | L. Sermeus | TE/ABT |
| 95 | 5.17 | AD closing / restart | milestone | 0d | 2015-05-15 | 2015-05-15 | 8FF | 635d |  | finish no earlier than 2013-11-15 |  | _key date |
| 96 | 5.18 | Install septa |  | 2mo | 2015-06-01 | 2015-07-30 |  | 581d |  | start no earlier than 2015-06-01 | J. Borburgh | TE/ABT |
| 97 | 5.19 | Install power converters |  | 5mo | 2015-06-01 | 2015-10-30 |  | 515d |  | start no earlier than 2015-06-01 | G. Simonet | TE/EPC |
| 98 | 5.20 | Install RF |  | 3mo | 2015-07-01 | 2015-09-30 |  | 537d |  | start no earlier than 2015-07-01 | M.E. Angoletta | BE/RF |
| 99 | 5.21 | Install e-cooling |  | 3mo | 2015-07-01 | 2015-09-30 |  | 537d |  | start no earlier than 2015-07-01 | G. Tranquille | BE/BI |
| 100 | 5.22 | Cable connexions & Interlocks |  | 3mo | 2015-08-03 | 2015-11-02 |  | 514d |  | start no earlier than 2015-08-01 | P. Lelong | EN/EL |
| 101 | 5.23 | Install instrumentation |  | 2mo | 2015-09-01 | 2015-10-30 |  | 515d |  | start no earlier than 2015-09-01 | G. Tranquille | BE/BI |
| 102 | 5.24 | Vacuum system |  | 4mo | 2015-09-01 | 2016-01-14 |  | 471d |  | start no earlier than 2015-09-01 | R. Kersevan | TE/VSC |
| 103 | 5.25 | Connection AD-ring to ELENA |  | 60d | 2015-12-01 | 2016-03-07 | 9SS | -1028d | 0d |  |  |  |
| 104 | 5.26 | Various (connexion to cooling; access door, …) |  | 3mo | 2016-01-04 | 2016-04-04 |  | 414d |  | start no earlier than 2016-01-01 |  |  |
| 105 | 5.27 | Commissioning ELENA (H-) |  | 3mo | 2016-04-01 | 2016-07-01 |  | -1200d | 0d | start no earlier than 2016-04-01 |  |  |
| 108 | 6 | **Redevelopment TL towards experiments** |  | 1d? | 2012-02-01 | 2012-02-01 |  |  |  |  |  |  |
| 109 | 6.1 | Installation TL |  | 5mo | 2016-12-01 | 2017-05-17 |  | -1462d | 0d | start no earlier than 2016-12-01 |  | _key date |
| 111 | 6.2 | Commissioning ELENA - Experiments |  | 6mo | 2017-05-18 | 2017-11-17 | 109 | -1462d | 0d |  |  | _key date |
| 113 | 7 | **Installation Gbar** |  | 1d? | 2012-02-01 | 2012-02-01 |  |  |  |  |  |  |
| 114 | 7.1 | Installation Gbar experiment |  | 1d? | 2012-02-01 | 2012-02-01 |  | 0d |  |  |  | _key date |
| 116 | 7.2 | Installation Gbar TL |  | 1d? | 2012-02-01 | 2012-02-01 |  | 0d |  |  |  | _key date |
| 118 | 7.3 | Connexion Gbar-Elena |  | 1d? | 2012-02-01 | 2012-02-01 |  | 0d |  |  |  | _key date |
